# CDM Classic

Schedule from MS Project, 2000-02-25 to 2000-02-25.

## Calendars

- Standard: Mon-Fri 08:00-12:00, 13:00-17:00; Sat-Sun off.

## Resources

| Resource |
| --- |
| Project Administrator |
| Project Manager |
| Project Staff |
| Project Sponsor |
| Bid Manager |
| Consulting Business Manager |
| Client Project Manager |
| Project Coordinator |
| Quality Manager |
| Configuration Manager |
| Business Analyst |
| Business Line Manager |
| User |
| IS Support Staff |
| System Architect |
| Network Engineer |
| IS Operations Staff |
| Technical Expert |
| Reviewer |
| Quality Auditor |
| Unassigned Resource |
| Database Designer |
| Internal Auditor |
| Technical Writer |
| Lead Tester |
| Module Designer |
| Development Database Admin |
| Tester |
| Production Database Admin |
| System Administrator |
| Programmer |
| Trainer |
| Application Administrator |
| Repository Administrator |
| Technical Analyst |

## Schedule

| ID | WBS | Task | Type | Duration | Start | Finish | Predecessors | Total slack | Resources | Text2 | Text3 | Text1 |
| --- | --- | --- | --- | --- | --- | --- | --- | --- | --- | --- | --- | --- |
| 1 | A | **Definition** |  | 0d | 2000-02-25 | 2000-02-25 |  | 0d |  |  |  |  |
| 2 | A.PL.PLAN | **Project Planning** |  | 0d | 2000-02-25 | 2000-02-25 |  | 0d |  | PL | PLAN |  |
| 3 | A.PL.BEG | Begin Project Planning | milestone | 0h | 2000-02-25 | 2000-02-25 |  | 0d |  | PL | PLAN |  |
| 4 | A.CR.010 | Establish Scope, Objectives and Approach | milestone | 0h | 2000-02-25 | 2000-02-25 | 3 | 0d | Project Administrator; Project Manager; Project Staff; Project Sponsor; Bid Manager; Consulting Business Manager; Client Project Manager | CR | PLAN | Scope, Objectives and Approach |
| 5 | A.CR.020 | Define Control and Reporting Strategies, Standards & Procedur | milestone | 0h | 2000-02-25 | 2000-02-25 | 4 | 0d | Project Coordinator; Project Manager; Client Project Manager | CR | PLAN | C&R Strategies, Stds & Procs |
| 6 | A.CR.030 | Establish Management Plans | milestone | 0h | 2000-02-25 | 2000-02-25 | 16, 15, 9, 5 | 0d | Project Coordinator; Project Manager; Quality Manager; Project Staff; Project Sponsor; Consulting Business Manager; Client Project Manager | CR | PLAN | Quality Plan |
| 7 | A.WM.010 | Define Work Management Strategies, Standards and Procedures | milestone | 0h | 2000-02-25 | 2000-02-25 | 4 | 0d | Project Coordinator; Project Manager; Client Project Manager | WM | PLAN | WM Strategies, Stds & Procs |
| 8 | A.WM.020 | Establish Project Workplan | milestone | 0h | 2000-02-25 | 2000-02-25 | 7FS-5% | 0d | Project Coordinator; Project Manager; Client Project Manager | WM | PLAN | Project Workplan |
| 9 | A.WM.030 | Establish Finance Plan | milestone | 0h | 2000-02-25 | 2000-02-25 | 13FS-5%, 8FS-5% | 0d | Project Coordinator; Project Manager; Consulting Business Manager; Client Project Manager | WM | PLAN | Finance Plan |
| 10 | A.RM.010 | Define Resource Management Strategies, Standards and Procedur | milestone | 0h | 2000-02-25 | 2000-02-25 | 4 | 0d | Project Coordinator; Project Manager; Client Project Manager | RM | PLAN | RM Strategies, Stds & Procs |
| 11 | A.RM.020 | Establish Staffing Plan | milestone | 0h | 2000-02-25 | 2000-02-25 | 10FS-5%, 8FS-5% | 0d | Project Coordinator; Project Manager; Client Project Manager; Consulting Business Manager | RM | PLAN | Staffing Plan |
| 12 | A.RM.030 | Establish Project Organization | milestone | 0h | 2000-02-25 | 2000-02-25 | 11 | 0d | Project Coordinator; Project Manager; Consulting Business Manager; Client Project Manager | RM | PLAN | Project Organization |
| 13 | A.RM.040 | Establish Physical Resource Plan | milestone | 0h | 2000-02-25 | 2000-02-25 | 10FS-5% | 0d | Project Coordinator; Project Manager; Client Project Manager | RM | PLAN | Physical Resource Plan |
| 14 | A.RM.050 | Establish Project Infrastructure | milestone | 0h | 2000-02-25 | 2000-02-25 | 13 | 0d | Project Coordinator; Project Manager; Client Project Manager | RM | PLAN | Project Infrastructure |
| 15 | A.QM.010 | Plan Quality Management Strategies, Standards and Procedures | milestone | 0h | 2000-02-25 | 2000-02-25 | 4 | 0d | Project Manager; Quality Manager; Client Project Manager | QM | PLAN | QM Strategies, Stds & Procs |
| 16 | A.CM.010 | Plan Configuration Management Strategies, Standards and Proce | milestone | 0h | 2000-02-25 | 2000-02-25 | 4 | 0d | Project Manager; Configuration Manager; Client Project Manager | CM | PLAN | CM Strategies, Stds & Procs |
| 17 | A.PL.END | End Project Planning | milestone | 0h | 2000-02-25 | 2000-02-25 | 14, 12, 6 | 0d |  | PL | PLAN |  |
| 18 | A.RD.EXEC | **Business Requirements Definition** |  | 0d | 2000-02-25 | 2000-02-25 |  | 0d |  | RD | EXEC |  |
| 19 | A.RD.BEG | Begin Definition Execution | milestone | 0h | 2000-02-25 | 2000-02-25 | 17 | 0d |  | RD | EXEC |  |
| 20 | A.RD.010 | Create Business Process Model | milestone | 0h | 2000-02-25 | 2000-02-25 | 27, 25 | 0d | Business Analyst | RD | EXEC | Business Process Model |
| 21 | A.RD.020 | Obtain High-level Business Descriptions | milestone | 0h | 2000-02-25 | 2000-02-25 | 20FS-5% | 0d | Business Analyst; Project Manager | RD | EXEC | HL Business Descriptions |
| 22 | A.RD.030 | Create High-level Business Function Model | milestone | 0h | 2000-02-25 | 2000-02-25 | 20FS-5% | 0d | Business Analyst; Project Manager | RD | EXEC | HL Business Function Model |
| 23 | A.RD.040 | Create Initial Business Data Model | milestone | 0h | 2000-02-25 | 2000-02-25 | 20FS-5% | 0d | Business Analyst; Project Manager | RD | EXEC | Init Business Data Model |
| 24 | A.ES.EXEC | **Existing System Examination** |  | 0d | 2000-02-25 | 2000-02-25 |  | 0d |  | ES | EXEC |  |
| 25 | A.ES.010 | Obtain Existing Reference Material | milestone | 0h | 2000-02-25 | 2000-02-25 | 19 | 0d | Business Analyst | ES | EXEC | Existing Reference Material |
| 26 | A.ES.020 | Document Organization Structures | milestone | 0h | 2000-02-25 | 2000-02-25 | 21FS-5% | 0d | Business Analyst | ES | EXEC | Organizational Structure Defn |
| 27 | A.ES.030 | Create High-level Existing System Data Model | milestone | 0h | 2000-02-25 | 2000-02-25 | 28FS-5% | 0d | Business Analyst; Project Manager | ES | EXEC | HL Existing System Data Model |
| 28 | A.ES.040 | Create Existing System Process Model | milestone | 0h | 2000-02-25 | 2000-02-25 | 25 | 0d | Business Analyst | ES | EXEC | Existing System Process Model |
| 29 | A.ES.050 | Document Existing System Interfaces | milestone | 0h | 2000-02-25 | 2000-02-25 | 27FS-5%, 25FS-5% | 0d | Business Analyst | ES | EXEC | Existing System Interfaces |
| 30 | A.ES.060 | Obtain Existing Technical Architecture | milestone | 0h | 2000-02-25 | 2000-02-25 | 25FS-5% | 0d | System Architect; Project Manager | ES | EXEC | Existing Technical Arch |
| 31 | A.ES.070 | Obtain Existing Capacity Plan | milestone | 0h | 2000-02-25 | 2000-02-25 | 25FS-5% | 0d | System Architect | ES | EXEC | Existing Capacity Plan |

| ID | WBS | Task | Type | Duration | Start | Finish | Predecessors | Total slack | Resources | Text2 | Text3 | Text1 |
| --- | --- | --- | --- | --- | --- | --- | --- | --- | --- | --- | --- | --- |
| 32 | A.TA.EXEC | **Technical Architecture** |  | 0d | 2000-02-25 | 2000-02-25 |  | 0d |  | TA | EXEC |  |
| 33 | A.TA.010 | Document System Interface Requirements | milestone | 0h | 2000-02-25 | 2000-02-25 | 23FS-5%, 21FS-5%, 29 | 0d | Business Analyst | TA | EXEC | System Interface Requirements |
| 34 | A.TA.020 | Prepare Initial Capacity Plan | milestone | 0h | 2000-02-25 | 2000-02-25 | 38FS-5%, 31, 33FS-5%, 30, 26, 22FS-5% | 0d | System Architect | TA | EXEC | Initial Capacity Plan |
| 35 | A.TA.030 | Prepare Initial Technical Architecture | milestone | 0h | 2000-02-25 | 2000-02-25 | 34FS-5% | 0d | Network Engineer; Project Manager; System Architect | TA | EXEC | Initial Technical Architecture |
| 36 | A.TA.040 | Document High-Level System Operational Requirements | milestone | 0h | 2000-02-25 | 2000-02-25 | 35 | 0d | Project Manager; System Architect | TA | EXEC | HL System Operational Reqs |
| 37 | A.CV.EXEC | **Data Conversion** |  | 0d | 2000-02-25 | 2000-02-25 |  | 0d |  | CV | EXEC |  |
| 38 | A.CV.010 | Document Data Conversion Requirements | milestone | 0h | 2000-02-25 | 2000-02-25 | 23 | 0d | Business Analyst; Technical Expert | CV | EXEC | Data Conversion Requirements |
| 39 | A.DO.EXEC | **Documentation** |  | 0d | 2000-02-25 | 2000-02-25 |  | 0d |  | DO | EXEC |  |
| 40 | A.DO.010 | Prepare Glossary | milestone | 0h | 2000-02-25 | 2000-02-25 | 23FS-5%, 21FS-5% | 0d | Business Analyst; Technical Expert | DO | EXEC | Glossary |
| 41 | A.DO.END | End Definition Execution | milestone | 0h | 2000-02-25 | 2000-02-25 | 46, 40, 36 | 0d |  | DO | EXEC |  |
| 42 | A.CT.CTRL | **Phase Control** |  | 0d | 2000-02-25 | 2000-02-25 |  | 0d |  | CT | CTRL |  |
| 43 | A.CT.BEG | Begin Phase Control | milestone | 0h | 2000-02-25 | 2000-02-25 | 19 | 0d |  | CT | CTRL |  |
| 44 | A.CT.SUM | Phase Control | milestone | 0h | 2000-02-25 | 2000-02-25 | 43 | 0d | Project Administrator; Project Coordinator; Project Staff; Project Manager; Quality Manager; Reviewer; Configuration Manager; Quality Auditor; Project Sponsor; Consulting Business Manager; Client Project Manager | CT | CTRL |  |
| 45 | A.CT.RES | Unallocated Reserve | milestone | 0h | 2000-02-25 | 2000-02-25 | 43 | 0d | Unassigned Resource | CT | CTRL |  |
| 46 | A.CT.END | End Phase Control | milestone | 0h | 2000-02-25 | 2000-02-25 | 45, 44 | 0d |  | CT | CTRL |  |
| 47 | A.CO.COMP | **Phase Completion** |  | 0d | 2000-02-25 | 2000-02-25 |  | 0d |  | CO | COMP |  |
| 48 | A.CO.BEG | Begin Phase Completion | milestone | 0h | 2000-02-25 | 2000-02-25 | 41 | 0d |  | CO | COMP |  |
| 49 | A.CR.080 | Secure Client Phase Acceptance | milestone | 0h | 2000-02-25 | 2000-02-25 | 53FS-7.5%, 52FS-7.5%, 51FS-10% | 0d | Project Administrator; Project Coordinator; Project Manager; Project Sponsor; Client Project Manager | CR | COMP | Client Phase Acceptance |
| 50 | A.RM.080 | Release Staff | milestone | 0h | 2000-02-25 | 2000-02-25 | 48 | 0d | Project Coordinator; Project Staff; Project Manager; Client Project Manager | RM | COMP | Released Staff |
| 51 | A.RM.090 | Release Physical Resources | milestone | 0h | 2000-02-25 | 2000-02-25 | 50 | 0d | Project Coordinator; Project Manager | RM | COMP | Released Physical Resources |
| 52 | A.QM.050 | Perform Quality Assessment | milestone | 0h | 2000-02-25 | 2000-02-25 | 48 | 0d | Project Manager; Quality Auditor | QM | COMP | Quality Report |
| 53 | A.CM.060 | Audit Key Deliverables | milestone | 0h | 2000-02-25 | 2000-02-25 | 48 | 0d | Project Administrator; Project Manager; Configuration Manager | CM | COMP | Audited Phase Baseline |
| 54 | A.CO.END | End Phase Completion | milestone | 0h | 2000-02-25 | 2000-02-25 | 49 | 0d |  | CO | COMP |  |
| 55 | B | **Analysis** |  | 0d | 2000-02-25 | 2000-02-25 |  | 0d |  |  |  |  |
| 56 | B.PL.PLAN | **Phase Planning** |  | 0d | 2000-02-25 | 2000-02-25 |  | 0d |  | PL | PLAN |  |
| 57 | B.PL.BEG | Begin Phase Planning | milestone | 0h | 2000-02-25 | 2000-02-25 | 19 | 0d |  | PL | PLAN |  |
| 58 | B.PL.SUM | Review and Revise Project Plans | milestone | 0h | 2000-02-25 | 2000-02-25 | 57 | 0d | Project Administrator; Project Coordinator; Project Staff; Project Manager; Quality Manager; Configuration Manager; Project Sponsor; Consulting Business Manager; Client Project Manager | PL | PLAN |  |
| 59 | B.PL.END | End Phase Planning | milestone | 0h | 2000-02-25 | 2000-02-25 | 58 | 0d |  | PL | PLAN |  |

| ID | WBS | Task | Type | Duration | Start | Finish | Predecessors | Total slack | Resources | Text2 | Text3 | Text1 |
| --- | --- | --- | --- | --- | --- | --- | --- | --- | --- | --- | --- | --- |
| 60 | B.RD.EXEC | **Business Requirements Definition** |  | 0d | 2000-02-25 | 2000-02-25 |  | 0d |  | RD | EXEC |  |
| 61 | B.RD.BEG | Begin Analysis Execution | milestone | 0h | 2000-02-25 | 2000-02-25 | 59, 41 | 0d |  | RD | EXEC |  |
| 62 | B.RD.050 | Collect Detailed Business Information | milestone | 0h | 2000-02-25 | 2000-02-25 | 61 | 0d | Business Analyst; Project Manager | RD | EXEC | Detailed Business Descriptions |
| 63 | B.RD.060 | Construct Business Data Model | milestone | 0h | 2000-02-25 | 2000-02-25 | 62FS-5%, 70FS-5%, 71 | 0d | Business Analyst; Project Manager | RD | EXEC | Business Data Model |
| 64 | B.RD.070 | Construct Detailed Business Function Model | milestone | 0h | 2000-02-25 | 2000-02-25 | 62FS-5%, 70, 71 | 0d | Business Analyst; Project Manager | RD | EXEC | Det Business Function Model |
| 65 | B.RD.080 | Construct System Data Model | milestone | 0h | 2000-02-25 | 2000-02-25 | 72, 64FS-5%, 63FS-5% | 0d | Business Analyst; System Architect; Project Manager | RD | EXEC | System Data Model |
| 66 | B.RD.090 | Construct System Function Model | milestone | 0h | 2000-02-25 | 2000-02-25 | 72, 64FS-5%, 63FS-5% | 0d | Business Analyst; System Architect; Project Manager | RD | EXEC | System Function Model |
| 67 | B.RD.100 | Create System Process Model | milestone | 0h | 2000-02-25 | 2000-02-25 | 72, 64FS-5%, 63FS-5% | 0d | Business Analyst; System Architect; Project Manager | RD | EXEC | System Process Model |
| 68 | B.ES.EXEC | **Existing System Examination** |  | 0d | 2000-02-25 | 2000-02-25 |  | 0d |  | ES | EXEC |  |
| 69 | B.ES.080 | Produce Revised Existing Technical Architecture | milestone | 0h | 2000-02-25 | 2000-02-25 | 61 | 0d | Project Manager; System Architect | ES | EXEC | Revised Exp Technical Architec |
| 70 | B.ES.090 | Produce Existing System Function Description | milestone | 0h | 2000-02-25 | 2000-02-25 | 61 | 0d | Business Analyst; Project Manager | ES | EXEC | Exg Sys Function Description |
| 71 | B.ES.100 | Produce Detailed Existing System Data Model | milestone | 0h | 2000-02-25 | 2000-02-25 | 61 | 0d | Business Analyst; Project Manager | ES | EXEC | Det Exg System Data Model |
| 72 | B.ES.110 | Produce Existing Operational Procedures Description | milestone | 0h | 2000-02-25 | 2000-02-25 | 61 | 0d | System Architect; Project Manager | ES | EXEC | Exg Open Procedures Desc |
| 73 | B.TA.EXEC | **Technical Architecture** |  | 0d | 2000-02-25 | 2000-02-25 |  | 0d |  | TA | EXEC |  |
| 74 | B.TA.050 | Define Detailed System Operational Requirements | milestone | 0h | 2000-02-25 | 2000-02-25 | 67FS-5%, 66FS-5%, 65FS-5% | 0d | Project Manager; System Architect | TA | EXEC | Det System Operational Reqs |
| 75 | B.TA.060 | Develop Hardware and Software Foundation Definition | milestone | 0h | 2000-02-25 | 2000-02-25 | 69, 74FS-5% | 0d | Business Analyst; Network Engineer; System Architect | TA | EXEC | HW and SW Foundation Definit |
| 76 | B.TA.070 | Develop Distribution Architecture | milestone | 0h | 2000-02-25 | 2000-02-25 | 74FS-5%, 69 | 0d | Database Designer; System Architect; Project Manager | TA | EXEC | Distribution Architecture |
| 77 | B.TA.080 | Develop Recovery and Fallback Strategy | milestone | 0h | 2000-02-25 | 2000-02-25 | 69, 74FS-5% | 0d | Business Analyst; System Architect | TA | EXEC | Recovery and Fallback Strategy |
| 78 | B.TA.090 | Develop Security and Control Strategy | milestone | 0h | 2000-02-25 | 2000-02-25 | 74FS-5%, 69 | 0d | Business Analyst; System Architect | TA | EXEC | Security and Control Strategy |
| 79 | B.TA.100 | Develop User Interface Style Definition | milestone | 0h | 2000-02-25 | 2000-02-25 | 74FS-5%, 69 | 0d | Business Analyst; Technical Expert | TA | EXEC | User Interface Style Defn |
| 80 | B.TA.110 | Develop Revised Capacity Plan | milestone | 0h | 2000-02-25 | 2000-02-25 | 74FS-5%, 69 | 0d | Business Analyst; System Architect | TA | EXEC | Revised Capacity Plan |
| 81 | B.CV.EXEC | **Data Conversion** |  | 0d | 2000-02-25 | 2000-02-25 |  | 0d |  | CV | EXEC |  |
| 82 | B.CV.020 | Define Data Conversion Strategy | milestone | 0h | 2000-02-25 | 2000-02-25 | 78FS-5%, 76FS-5%, 75FS-5% | 0d | System Architect | CV | EXEC | Data Conversion Strategy |
| 83 | B.CV.030 | Define Data Conversion Workplan | milestone | 0h | 2000-02-25 | 2000-02-25 | 82 | 0d | Business Analyst; Project Manager | CV | EXEC | Data Conversion Workplan |

| ID | WBS | Task | Type | Duration | Start | Finish | Predecessors | Total slack | Resources | Text2 | Text3 | Text1 |
| --- | --- | --- | --- | --- | --- | --- | --- | --- | --- | --- | --- | --- |
| 84 | B.DO.EXEC | **Documentation** |  | 0d | 2000-02-25 | 2000-02-25 |  | 0d |  | DO | EXEC |  |
| 85 | B.DO.020 | Specify Documentation Requirements | milestone | 0h | 2000-02-25 | 2000-02-25 | 61 | 0d | Project Manager; Technical Writer | DO | EXEC | Documentation Requirements |
| 86 | B.DO.030 | Determine Documentation Standards | milestone | 0h | 2000-02-25 | 2000-02-25 | 61 | 0d | Technical Writer | DO | EXEC | Documentation Standards |
| 87 | B.TE.EXEC | **Testing** |  | 0d | 2000-02-25 | 2000-02-25 |  | 0d |  | TE | EXEC |  |
| 88 | B.TE.010 | Develop Testing Strategy | milestone | 0h | 2000-02-25 | 2000-02-25 | 67 | 0d | Lead Tester | TE | EXEC | Testing Strategy |
| 89 | B.TR.EXEC | **Training** |  | 0d | 2000-02-25 | 2000-02-25 |  | 0d |  | TR | EXEC |  |
| 90 | B.TR.010 | Define Training Requirements | milestone | 0h | 2000-02-25 | 2000-02-25 | 75FS-5% | 0d | Business Analyst; Project Manager | TR | EXEC | Training Requirements |
| 91 | B.TR.020 | Define Training Plan | milestone | 0h | 2000-02-25 | 2000-02-25 | 90 | 0d | Business Analyst; Project Manager | TR | EXEC | Training Plan |
| 92 | B.TS.EXEC | **Transition** |  | 0d | 2000-02-25 | 2000-02-25 |  | 0d |  | TS | EXEC |  |
| 93 | B.TS.010 | Define Initial Cut-over Strategy | milestone | 0h | 2000-02-25 | 2000-02-25 | 91FS-5%, 83FS-5% | 0d | Business Analyst; Project Manager | TS | EXEC | Initial Cut-over Strategy |
| 94 | B.TS.END | End Analysis Execution | milestone | 0h | 2000-02-25 | 2000-02-25 | 99, 86, 85, 88, 77, 79, 80, 93 | 0d |  | TS | EXEC |  |
| 95 | B.CT.CTRL | **Phase Control** |  | 0d | 2000-02-25 | 2000-02-25 |  | 0d |  | CT | CTRL |  |
| 96 | B.CT.BEG | Begin Phase Control | milestone | 0h | 2000-02-25 | 2000-02-25 | 61 | 0d |  | CT | CTRL |  |
| 97 | B.CT.SUM | Phase Control | milestone | 0h | 2000-02-25 | 2000-02-25 | 96 | 0d | Project Administrator; Project Coordinator; Project Manager; Quality Manager; Reviewer; Configuration Manager; Quality Auditor; Project Staff; Project Sponsor; Consulting Business Manager; Client Project Manager | CT | CTRL |  |
| 98 | B.CT.RES | Unallocated Reserve | milestone | 0h | 2000-02-25 | 2000-02-25 | 96 | 0d | Unassigned Resource | CT | CTRL |  |
| 99 | B.CT.END | End Phase Control | milestone | 0h | 2000-02-25 | 2000-02-25 | 98, 97 | 0d |  | CT | CTRL |  |
| 100 | B.CO.COMP | **Phase Completion** |  | 0d | 2000-02-25 | 2000-02-25 |  | 0d |  | CO | COMP |  |
| 101 | B.CO.BEG | Begin Phase Completion | milestone | 0h | 2000-02-25 | 2000-02-25 | 94, 54 | 0d |  | CO | COMP |  |
| 102 | B.CR.080 | Secure Client Phase Acceptance | milestone | 0h | 2000-02-25 | 2000-02-25 | 106FS-7.5%, 105FS-7.5%, 104FS-10% | 0d | Project Administrator; Project Coordinator; Project Manager; Project Sponsor; Client Project Manager | CR | COMP | Client Phase Acceptance |
| 103 | B.RM.080 | Release Staff | milestone | 0h | 2000-02-25 | 2000-02-25 | 101 | 0d | Project Coordinator; Project Staff; Project Manager; Client Project Manager | RM | COMP | Released Staff |
| 104 | B.RM.090 | Release Physical Resources | milestone | 0h | 2000-02-25 | 2000-02-25 | 103 | 0d | Project Coordinator; Project Manager | RM | COMP | Released Physical Resources |
| 105 | B.QM.050 | Perform Quality Assessment | milestone | 0h | 2000-02-25 | 2000-02-25 | 101 | 0d | Project Manager; Quality Auditor | QM | COMP | Quality Report |
| 106 | B.CM.060 | Audit Key Deliverables | milestone | 0h | 2000-02-25 | 2000-02-25 | 101 | 0d | Project Administrator; Project Manager; Configuration Manager | QM | COMP | Audited Phase Baseline |
| 107 | B.CO.END | End Phase Completion | milestone | 0h | 2000-02-25 | 2000-02-25 | 102 | 0d |  | CO | COMP |  |

| ID | WBS | Task | Type | Duration | Start | Finish | Predecessors | Total slack | Resources | Text2 | Text3 | Text1 |
| --- | --- | --- | --- | --- | --- | --- | --- | --- | --- | --- | --- | --- |
| 108 | C | **Design** |  | 0d | 2000-02-25 | 2000-02-25 |  | 0d |  |  |  |  |
| 109 | C.PL.PLAN | **Phase Planning** |  | 0d | 2000-02-25 | 2000-02-25 |  | 0d |  | PL | PLAN |  |
| 110 | C.PL.BEG | Begin Phase Planning | milestone | 0h | 2000-02-25 | 2000-02-25 | 61, 59 | 0d |  | PL | PLAN |  |
| 111 | C.PL.SUM | Review and Revise Project Plans | milestone | 0h | 2000-02-25 | 2000-02-25 | 110 | 0d | Project Administrator; Project Coordinator; Project Staff; Project Manager; Quality Manager; Configuration Manager; Project Sponsor; Consulting Business Manager; Client Project Manager | PL | PLAN |  |
| 112 | C.PL.END | End Phase Planning | milestone | 0h | 2000-02-25 | 2000-02-25 | 111 | 0d |  | PL | PLAN |  |
| 113 | C.TA.EXEC | **Technical Architecture** |  | 0d | 2000-02-25 | 2000-02-25 |  | 0d |  | TA | EXEC |  |
| 114 | C.TA.BEG | Begin Design Execution | milestone | 0h | 2000-02-25 | 2000-02-25 | 112, 94 | 0d |  | TA | EXEC |  |
| 115 | C.TA.120 | Create Capacity Plan | milestone | 0h | 2000-02-25 | 2000-02-25 | 119 | 0d | Database Designer; Project Manager; System Architect | TA | EXEC | Capacity Plan |
| 116 | C.TA.130 | Determine Performance Issues | milestone | 0h | 2000-02-25 | 2000-02-25 | 118, 123FS-7.5% | 0d | Module Designer; System Architect | TA | EXEC | Performance Issues |
| 117 | C.DB.EXEC | **Database Design and Build** |  | 0d | 2000-02-25 | 2000-02-25 |  | 0d |  | DB | EXEC |  |
| 118 | C.DB.010 | Create Logical Database Design | milestone | 0h | 2000-02-25 | 2000-02-25 | 122 | 0d | Business Analyst; Database Designer | DB | EXEC | Logical Database Design |
| 119 | C.DB.020 | Create Index Design | milestone | 0h | 2000-02-25 | 2000-02-25 | 125FS-7.5% | 0d | Database Designer; Development Database Admin | DB | EXEC | Index Design |
| 120 | C.DB.030 | Create Database Object Authorization Scheme | milestone | 0h | 2000-02-25 | 2000-02-25 | 125FS-7.5% | 0d | Database Designer; Development Database Admin | DB | EXEC | DB Object Authorization Scheme |
| 121 | C.MD.EXEC | **Module Design and Build** |  | 0d | 2000-02-25 | 2000-02-25 |  | 0d |  | MD | EXEC |  |
| 122 | C.MD.010 | Define Design Standards | milestone | 0h | 2000-02-25 | 2000-02-25 | 114 | 0d | Database Designer; Module Designer; Technical Expert; Project Manager | MD | EXEC | Design Standards |
| 123 | C.MD.030 | Design Application | milestone | 0h | 2000-02-25 | 2000-02-25 | 118FS-2.5% | 0d | Business Analyst; Module Designer; System Architect | MD | EXEC | Application Design |
| 124 | C.MD.040 | Create Module Functional Documentation | milestone | 0h | 2000-02-25 | 2000-02-25 | 123 | 0d | Module Designer; Technical Writer | MD | EXEC | Module Funcnl Documentation |
| 125 | C.MD.050 | Create Module Technical Documentation | milestone | 0h | 2000-02-25 | 2000-02-25 | 118, 116, 124FF | 0d | Module Designer | MD | EXEC | Module Techl Documentation |
| 126 | C.MD.060 | Create Menu Structure | milestone | 0h | 2000-02-25 | 2000-02-25 | 123 | 0d | Module Designer | MD | EXEC | Menu Structure |
| 127 | C.MD.070 | Design Audit Facilities | milestone | 0h | 2000-02-25 | 2000-02-25 | 123 | 0d | Development Database Admin; Module Designer | MD | EXEC | Audit Facilities |
| 128 | C.CV.EXEC | **Data Conversion** |  | 0d | 2000-02-25 | 2000-02-25 |  | 0d |  | CV | EXEC |  |
| 129 | C.CV.040 | Design Data Conversion Modules | milestone | 0h | 2000-02-25 | 2000-02-25 | 119FS-7.5%, 120FS-7.5%, 127FS-7.5% | 0d | Module Designer; System Architect | CV | EXEC | Data Conversion Module Design |
| 130 | C.DO.EXEC | **Documentation** |  | 0d | 2000-02-25 | 2000-02-25 |  | 0d |  | DO | EXEC |  |
| 131 | C.DO.040 | Create Documentation Procedures and Environment | milestone | 0h | 2000-02-25 | 2000-02-25 | 114 | 0d | Technical Writer; Project Manager | DO | EXEC | Docn Procedures and Env |
| 132 | C.DO.050 | Produce Documentation Prototypes and Templates | milestone | 0h | 2000-02-25 | 2000-02-25 | 114 | 0d | Technical Writer | DO | EXEC | Docn Prototypes and Templates |
| 133 | C.DO.060 | Produce Initial User Reference | milestone | 0h | 2000-02-25 | 2000-02-25 | 126FS-7.5%, 124FS-7.5%, 132, 131 | 0d | Module Designer; Technical Writer | DO | EXEC | Initial User Reference |
| 134 | C.DO.070 | Produce Initial User Guide | milestone | 0h | 2000-02-25 | 2000-02-25 | 124FS-2.5%, 132, 131 | 0d | Module Designer; Technical Writer | DO | EXEC | Initial User Guide |
| 135 | C.DO.080 | Produce High-level Technical Reference | milestone | 0h | 2000-02-25 | 2000-02-25 | 132, 131 | 0d | Module Designer; Technical Writer | DO | EXEC | High-level Technical Reference |
| 136 | C.DO.090 | Produce Initial System Operations Guide | milestone | 0h | 2000-02-25 | 2000-02-25 | 124FS-7.5%, 132, 131 | 0d | Technical Writer | DO | EXEC | Init System Operations Guide |

| ID | WBS | Task | Type | Duration | Start | Finish | Predecessors | Total slack | Resources | Text2 | Text3 | Text1 |
| --- | --- | --- | --- | --- | --- | --- | --- | --- | --- | --- | --- | --- |
| 137 | C.TE.EXEC | **Testing** |  | 0d | 2000-02-25 | 2000-02-25 |  | 0d |  | TE | EXEC |  |
| 138 | C.TE.020 | Develop System Process Test Model | milestone | 0h | 2000-02-25 | 2000-02-25 | 127, 136, 134FS-7.5%, 133FS-7.5% | 0d | Tester; Lead Tester | TE | EXEC | System Process Test Model |
| 139 | C.TE.030 | Develop Module and Module Integration Test Plan | milestone | 0h | 2000-02-25 | 2000-02-25 | 124 | 0d | Lead Tester | TE | EXEC | Module and Mod Intgn Test Plan |
| 140 | C.TR.EXEC | **Training** |  | 0d | 2000-02-25 | 2000-02-25 |  | 0d |  | TR | EXEC |  |
| 141 | C.TR.030 | Create Initial Training Materials | milestone | 0h | 2000-02-25 | 2000-02-25 | 134FS-2.5% | 0d | Technical Writer | TR | EXEC | Initial Training Materials |
| 142 | C.TS.EXEC | **Transition** |  | 0d | 2000-02-25 | 2000-02-25 |  | 0d |  | TS | EXEC |  |
| 143 | C.TS.020 | Define Cut-over Strategy | milestone | 0h | 2000-02-25 | 2000-02-25 | 129 | 0d | Business Analyst; Project Manager | TS | EXEC | Cut-over Strategy |
| 144 | C.TS.END | End Design Execution | milestone | 0h | 2000-02-25 | 2000-02-25 | 138, 149, 133, 141, 136, 135, 115, 143, 139 | 0d |  | TS | EXEC |  |
| 145 | C.CT.CTRL | **Phase Control** |  | 0d | 2000-02-25 | 2000-02-25 |  | 0d |  | CT | CTRL |  |
| 146 | C.CT.BEG | Begin Phase Control | milestone | 0h | 2000-02-25 | 2000-02-25 | 114 | 0d |  | CT | CTRL |  |
| 147 | C.CT.SUM | Phase Control | milestone | 0h | 2000-02-25 | 2000-02-25 | 146 | 0d | Project Administrator; Project Coordinator; Project Staff; Project Manager; Quality Manager; Reviewer; Configuration Manager; Quality Auditor; Project Sponsor; Consulting Business Manager; Client Project Manager | CT | CTRL |  |
| 148 | C.CT.RES | Unallocated Reserve | milestone | 0h | 2000-02-25 | 2000-02-25 | 146 | 0d | Unassigned Resource | CT | CTRL |  |
| 149 | C.CT.END | End Phase Control | milestone | 0h | 2000-02-25 | 2000-02-25 | 148, 147 | 0d |  | CT | CTRL |  |
| 150 | C.CO.COMP | **Phase Completion** |  | 0d | 2000-02-25 | 2000-02-25 |  | 0d |  | CO | COMP |  |
| 151 | C.CO.BEG | Begin Phase Completion | milestone | 0h | 2000-02-25 | 2000-02-25 | 107, 144 | 0d |  | CO | COMP |  |
| 152 | C.CR.080 | Secure Client Phase Acceptance | milestone | 0h | 2000-02-25 | 2000-02-25 | 156FS-7.5%, 155FS-7.5%, 154FS-10% | 0d | Project Administrator; Project Coordinator; Project Manager; Project Sponsor; Client Project Manager | CR | COMP | Client Phase Acceptance |
| 153 | C.RM.080 | Release Staff | milestone | 0h | 2000-02-25 | 2000-02-25 | 151 | 0d | Project Coordinator; Project Staff; Project Manager; Client Project Manager | RM | COMP | Released Staff |
| 154 | C.RM.090 | Release Physical Resources | milestone | 0h | 2000-02-25 | 2000-02-25 | 153 | 0d | Project Coordinator; Project Manager | RM | COMP | Released Physical Resources |
| 155 | C.QM.050 | Perform Quality Assessment | milestone | 0h | 2000-02-25 | 2000-02-25 | 151 | 0d | Project Manager; Quality Auditor | QM | COMP | Quality Report |
| 156 | C.CM.060 | Audit Key Deliverables | milestone | 0h | 2000-02-25 | 2000-02-25 | 151 | 0d | Project Administrator; Project Manager; Configuration Manager | CM | COMP | Audited Phase Baseline |
| 157 | C.CO.END | End Phase Completion | milestone | 0h | 2000-02-25 | 2000-02-25 | 152 | 0d |  | CO | COMP |  |
| 158 | D | **Build** |  | 0d | 2000-02-25 | 2000-02-25 |  | 0d |  |  |  |  |
| 159 | D.PL.PLAN | **Phase Planning** |  | 0d | 2000-02-25 | 2000-02-25 |  | 0d |  | PL | PLAN |  |
| 160 | D.PL.BEG | Begin Phase Planning | milestone | 0h | 2000-02-25 | 2000-02-25 | 114, 112 | 0d |  | PL | PLAN |  |
| 161 | D.PL.SUM | Review and Revise Project Plans | milestone | 0h | 2000-02-25 | 2000-02-25 | 160 | 0d | Project Administrator; Project Coordinator; Project Staff; Project Manager; Quality Manager; Configuration Manager; Project Sponsor; Consulting Business Manager; Client Project Manager | PL | PLAN |  |
| 162 | D.PL.END | End Phase Planning | milestone | 0h | 2000-02-25 | 2000-02-25 | 161 | 0d |  | PL | PLAN |  |

| ID | WBS | Task | Type | Duration | Start | Finish | Predecessors | Total slack | Resources | Text2 | Text3 | Text1 |
| --- | --- | --- | --- | --- | --- | --- | --- | --- | --- | --- | --- | --- |
| 163 | D.DB.EXEC | **Database Design and Build** |  | 0d | 2000-02-25 | 2000-02-25 |  | 0d |  | DB | EXEC |  |
| 164 | D.DB.BEG | Begin Build Execution | milestone | 0h | 2000-02-25 | 2000-02-25 | 162, 144 | 0d |  | DB | EXEC |  |
| 165 | D.DB.040 | Create Physical Database Design | milestone | 0h | 2000-02-25 | 2000-02-25 | 168 | 0d | Database Designer; Development Database Admin | DB | EXEC | Physical Database Design |
| 166 | D.DB.050 | Create Production Database DDL | milestone | 0h | 2000-02-25 | 2000-02-25 | 165 | 0d | Production Database Admin | DB | EXEC | Production Database DDL |
| 167 | D.MD.EXEC | **Module Design and Build** |  | 0d | 2000-02-25 | 2000-02-25 |  | 0d |  | MD | EXEC |  |
| 168 | D.MD.020 | Define Build Standards | milestone | 0h | 2000-02-25 | 2000-02-25 | 164 | 0d | Module Designer; Technical Expert; Project Manager | MD | EXEC | Build Standards |
| 169 | D.MD.080 | Create Development Environment | milestone | 0h | 2000-02-25 | 2000-02-25 | 168 | 0d | Database Designer; Development Database Admin; System Administrator; Project Manager | MD | EXEC | Development Environment |
| 170 | D.MD.090 | Create Application Code | milestone | 0h | 2000-02-25 | 2000-02-25 | 169 | 0d | Programmer | MD | EXEC | Application Code |
| 171 | D.CV.EXEC | **Data Conversion** |  | 0d | 2000-02-25 | 2000-02-25 |  | 0d |  | CV | EXEC |  |
| 172 | D.CV.050 | Code Conversion Modules | milestone | 0h | 2000-02-25 | 2000-02-25 | 169 | 0d | Programmer | CV | EXEC | Conversion Modules |
| 173 | D.CV.060 | Perform Conversion Module Test | milestone | 0h | 2000-02-25 | 2000-02-25 | 172FS-5% | 0d | Programmer; Technical Analyst | CV | EXEC | Conversion Module Test Results |
| 174 | D.DO.EXEC | **Documentation** |  | 0d | 2000-02-25 | 2000-02-25 |  | 0d |  | DO | EXEC |  |
| 175 | D.DO.100 | Complete User Reference | milestone | 0h | 2000-02-25 | 2000-02-25 | 164 | 0d | Programmer; Technical Writer | DO | EXEC | User Reference |
| 176 | D.DO.110 | Complete User Guide | milestone | 0h | 2000-02-25 | 2000-02-25 | 183 | 0d | Technical Writer | DO | EXEC | User Guide |
| 177 | D.DO.120 | Complete Technical Reference | milestone | 0h | 2000-02-25 | 2000-02-25 | 168, 169 | 0d | Module Designer; Programmer; Technical Writer | DO | EXEC | Detailed Technical Reference |
| 178 | D.DO.130 | Complete System Operations Guide | milestone | 0h | 2000-02-25 | 2000-02-25 | 183 | 0d | System Architect; System Administrator; Technical Writer | DO | EXEC | System Operations Guide |
| 179 | D.DO.140 | Provide Online Help Text | milestone | 0h | 2000-02-25 | 2000-02-25 | 175FS-5% | 0d | Programmer; Technical Writer | DO | EXEC | Online Help Text |
| 180 | D.TE.EXEC | **Testing** |  | 0d | 2000-02-25 | 2000-02-25 |  | 0d |  | TE | EXEC |  |
| 181 | D.TE.040 | Perform Module and Module Integration Test | milestone | 0h | 2000-02-25 | 2000-02-25 | 170FS-7.5% | 0d | Module Designer; Programmer; Project Manager | TE | EXEC | Module & Mod Intgn Test Result |
| 182 | D.TE.050 | Develop System Test Plan | milestone | 0h | 2000-02-25 | 2000-02-25 | 164 | 0d | Lead Tester | TE | EXEC | System Test Plan |
| 183 | D.TE.060 | Prepare System Test Environment | milestone | 0h | 2000-02-25 | 2000-02-25 | 192, 170FS-2.5%, 182, 166 | 0d | Development Database Admin; System Administrator; Lead Tester | TE | EXEC | System Test Environment |
| 184 | D.TE.070 | Perform System Test | milestone | 0h | 2000-02-25 | 2000-02-25 | 181FS-5%, 183, 173 | 0d | Module Designer; Programmer; Tester; Lead Tester | TE | EXEC | System Test Results |
| 185 | D.TE.080 | Develop Systems Integration Test Plan | milestone | 0h | 2000-02-25 | 2000-02-25 | 184FS-7.5% | 0d | Lead Tester | TE | EXEC | System Integration Test Plan |
| 186 | D.TE.090 | Develop Systems Integration Test Sequences | milestone | 0h | 2000-02-25 | 2000-02-25 | 185, 192FS-7.5% | 0d | Tester; Lead Tester | TE | EXEC | Systems Intgn Test Sequences |
| 187 | D.TE.100 | Perform Systems Integration Test | milestone | 0h | 2000-02-25 | 2000-02-25 | 186 | 0d | Module Designer; Programmer; Tester; Lead Tester | TE | EXEC | Systems Intgn Test Results |

| ID | WBS | Task | Type | Duration | Start | Finish | Predecessors | Total slack | Resources | Text2 | Text3 | Text1 |
| --- | --- | --- | --- | --- | --- | --- | --- | --- | --- | --- | --- | --- |
| 188 | D.TR.EXEC | **Training** |  | 0d | 2000-02-25 | 2000-02-25 |  | 0d |  | TR | EXEC |  |
| 189 | D.TR.050 | Create Training Database | milestone | 0h | 2000-02-25 | 2000-02-25 | 184 | 0d | Development Database Admin; Programmer; Trainer | TR | EXEC | Training Database |
| 190 | D.TR.060 | Complete Training Materials | milestone | 0h | 2000-02-25 | 2000-02-25 | 192, 184 | 0d | Trainer | TR | EXEC | Training Materials |
| 191 | D.TS.EXEC | **Transition** |  | 0d | 2000-02-25 | 2000-02-25 |  | 0d |  | TS | EXEC |  |
| 192 | D.TS.030 | Develop Installation Plan | milestone | 0h | 2000-02-25 | 2000-02-25 | 164 | 0d | Production Database Admin; Programmer; System Architect | TS | EXEC | Installation Plan |
| 193 | D.TS.END | End Build Execution | milestone | 0h | 2000-02-25 | 2000-02-25 | 198, 190, 189, 179, 178, 177, 176, 187 | 0d |  | TS | EXEC |  |
| 194 | D.CT.CTRL | **Phase Control** |  | 0d | 2000-02-25 | 2000-02-25 |  | 0d |  | CT | CTRL |  |
| 195 | D.CT.BEG | Begin Phase Control | milestone | 0h | 2000-02-25 | 2000-02-25 | 164 | 0d |  | CT | CTRL |  |
| 196 | D.CT.SUM | Phase Control | milestone | 0h | 2000-02-25 | 2000-02-25 | 195 | 0d | Project Administrator; Project Coordinator; Project Staff; Project Manager; Quality Manager; Reviewer; Configuration Manager; Quality Auditor; Project Sponsor; Consulting Business Manager; Client Project Manager | CT | CTRL |  |
| 197 | D.CT.RES | Unallocated Reserve | milestone | 0h | 2000-02-25 | 2000-02-25 | 195 | 0d | Unassigned Resource | CT | CTRL |  |
| 198 | D.CT.END | End Phase Control | milestone | 0h | 2000-02-25 | 2000-02-25 | 197, 196 | 0d |  | CT | CTRL |  |
| 199 | D.CO.COMP | **Phase Completion** |  | 0d | 2000-02-25 | 2000-02-25 |  | 0d |  | CO | COMP |  |
| 200 | D.CO.BEG | Begin Phase Completion | milestone | 0h | 2000-02-25 | 2000-02-25 | 193, 157 | 0d |  | CO | COMP |  |
| 201 | D.CR.080 | Secure Client Phase Acceptance | milestone | 0h | 2000-02-25 | 2000-02-25 | 205FS-7.5%, 204FS-7.5%, 203FS-10% | 0d | Project Administrator; Project Coordinator; Project Manager; Project Sponsor; Client Project Manager | CR | COMP | Client Phase Acceptance |
| 202 | D.RM.080 | Release Staff | milestone | 0h | 2000-02-25 | 2000-02-25 | 200 | 0d | Project Coordinator; Project Staff; Project Manager; Client Project Manager | RM | COMP | Released Staff |
| 203 | D.RM.090 | Release Physical Resources | milestone | 0h | 2000-02-25 | 2000-02-25 | 202 | 0d | Project Sponsor; Project Coordinator | RM | COMP | Released Physical Resources |
| 204 | D.QM.050 | Perform Quality Assessment | milestone | 0h | 2000-02-25 | 2000-02-25 | 200 | 0d | Project Manager; Quality Auditor | QM | COMP | Quality Report |
| 205 | D.CM.060 | Audit Key Deliverables | milestone | 0h | 2000-02-25 | 2000-02-25 | 200 | 0d | Project Administrator; Project Manager; Configuration Manager | CM | COMP | Audited Phase Baseline |
| 206 | C.CO.END | End Phase Completion | milestone | 0h | 2000-02-25 | 2000-02-25 | 201 | 0d |  | CO | COMP |  |
| 207 | E | **Transition** |  | 0d | 2000-02-25 | 2000-02-25 |  | 0d |  |  |  |  |
| 208 | E.PL.PLAN | **Phase Planning** |  | 0d | 2000-02-25 | 2000-02-25 |  | 0d |  | PL | PLAN |  |
| 209 | E.PL.BEG | Begin Phase Planning | milestone | 0h | 2000-02-25 | 2000-02-25 | 164, 162 | 0d |  | PL | PLAN |  |
| 210 | E.PL.SUM | Review and Revise Project Plans | milestone | 0h | 2000-02-25 | 2000-02-25 | 209 | 0d | Project Administrator; Project Coordinator; Project Staff; Project Manager; Quality Manager; Configuration Manager; Project Sponsor; Consulting Business Manager; Client Project Manager | PL | PLAN |  |
| 211 | E.PL.END | End Phase Planning | milestone | 0h | 2000-02-25 | 2000-02-25 | 210 | 0d |  | PL | PLAN |  |

| ID | WBS | Task | Type | Duration | Start | Finish | Predecessors | Total slack | Resources | Text2 | Text3 | Text1 |
| --- | --- | --- | --- | --- | --- | --- | --- | --- | --- | --- | --- | --- |
| 212 | E.CV.EXEC | **Data Conversion** |  | 0d | 2000-02-25 | 2000-02-25 |  | 0d |  | CV | EXEC |  |
| 213 | E.CV.BEG | Begin Transition Execution | milestone | 0h | 2000-02-25 | 2000-02-25 | 211, 193 | 0d |  | CV | EXEC |  |
| 214 | E.CV.070 | Convert and Verify Data | milestone | 0h | 2000-02-25 | 2000-02-25 | 227 | 0d | Production Database Admin; Project Manager; Programmer; System Administrator; Technical Analyst | CV | EXEC | Converted and Verified Data |
| 215 | E.TE.EXEC | **Testing** |  | 0d | 2000-02-25 | 2000-02-25 |  | 0d |  | TE | EXEC |  |
| 216 | E.TE.110 | Prepare Acceptance Test Environment | milestone | 0h | 2000-02-25 | 2000-02-25 | 213 | 0d | Production Database Admin; System Administrator; Project Manager | TE | EXEC | Acceptance Test Environment |
| 217 | E.TE.120 | Support Acceptance Test | milestone | 0h | 2000-02-25 | 2000-02-25 | 224 | 0d | Module Designer; Programmer; Production Database Admin; System Administrator; Project Manager | TE | EXEC | Acceptance Test Results |
| 218 | E.TR.EXEC | **Training** |  | 0d | 2000-02-25 | 2000-02-25 |  | 0d |  | TR | EXEC |  |
| 219 | E.TR.040 | Produce Client Maintenance Class Materials | milestone | 0h | 2000-02-25 | 2000-02-25 | 213 | 0d | Trainer | TR | EXEC | Client Maint Class Materials |
| 220 | E.TR.070 | Produce User Class Materials | milestone | 0h | 2000-02-25 | 2000-02-25 | 213 | 0d | Trainer | TR | EXEC | User Class Materials |
| 221 | E.TR.080 | Prepare Training Installation | milestone | 0h | 2000-02-25 | 2000-02-25 | 213 | 0d | Development Database Admin; System Administrator; Trainer; Project Manager | TR | EXEC | Training Installation |
| 222 | E.TR.090 | Train Users | milestone | 0h | 2000-02-25 | 2000-02-25 | 221, 220 | 0d | Trainer | TR | EXEC | Trainied Users |
| 223 | E.TR.100 | Train Administrators | milestone | 0h | 2000-02-25 | 2000-02-25 | 221 | 0d | Trainer | TR | EXEC | Trained Administrators |
| 224 | E.TR.110 | Train Acceptance Test Team | milestone | 0h | 2000-02-25 | 2000-02-25 | 222FS-7.5%, 216, 223 | 0d | Development Database Admin; Module Designer; System Administrator; Trainer | TR | EXEC | Trained Acceptance Test Team |
| 225 | E.TS.EXEC | **Transition** |  | 0d | 2000-02-25 | 2000-02-25 |  | 0d |  | TS | EXEC |  |
| 226 | E.TS.040 | Prepare Client Maintenance Environment | milestone | 0h | 2000-02-25 | 2000-02-25 | 219 | 0d | Development Database Admin; Programmer; System Administrator; Project Manager | TS | EXEC | Client Maintenance Environment |
| 227 | E.TS.050 | Prepare Production Environment | milestone | 0h | 2000-02-25 | 2000-02-25 | 213 | 0d | Production Database Admin; System Administrator; Project Manager | TS | EXEC | Production Environment |
| 228 | E.TS.060 | Go Production | milestone | 0h | 2000-02-25 | 2000-02-25 | 222, 223, 217, 226, 214 | 0d | System Administrator; Project Manager | TS | EXEC | System in Production |
| 229 | E.TS.070 | Shut Down Legacy System | milestone | 0h | 2000-02-25 | 2000-02-25 | 228 | 0d | Project Manager; System Administrator | TS | EXEC | Legacy System Shut Down |
| 230 | E.TS.END | End Transition Execution | milestone | 0h | 2000-02-25 | 2000-02-25 | 235, 229 | 0d |  | TS | EXEC |  |
| 231 | E.CT.CTRL | **Phase Control** |  | 0d | 2000-02-25 | 2000-02-25 |  | 0d |  | CT | CTRL |  |
| 232 | E.CT.BEG | Begin Phase Control | milestone | 0h | 2000-02-25 | 2000-02-25 | 213 | 0d |  | CT | CTRL |  |
| 233 | E.CT.SUM | Phase Control | milestone | 0h | 2000-02-25 | 2000-02-25 | 232 | 0d | Project Administrator; Project Coordinator; Project Staff; Project Manager; Quality Manager; Reviewer; Configuration Manager; Quality Auditor; Project Sponsor; Consulting Business Manager; Client Project Manager | CT | CTRL |  |
| 234 | E.CT.RES | Unallocated Reserve | milestone | 0h | 2000-02-25 | 2000-02-25 | 232 | 0d | Unassigned Resource | CT | CTRL |  |
| 235 | E.CT.END | End Phase Control | milestone | 0h | 2000-02-25 | 2000-02-25 | 234, 233 | 0d |  | CT | CTRL |  |

| ID | WBS | Task | Type | Duration | Start | Finish | Predecessors | Total slack | Resources | Text2 | Text3 | Text1 |
| --- | --- | --- | --- | --- | --- | --- | --- | --- | --- | --- | --- | --- |
| 236 | E.CO.COMP | **Phase Completion** |  | 0d | 2000-02-25 | 2000-02-25 |  | 0d |  | CO | COMP |  |
| 237 | E.CO.BEG | Begin Phase Completion | milestone | 0h | 2000-02-25 | 2000-02-25 | 206, 230 | 0d |  | CO | COMP |  |
| 238 | E.CR.080 | Secure Client Phase Acceptance | milestone | 0h | 2000-02-25 | 2000-02-25 | 242FS-7.5%, 241FS-7.5%, 240FS-10% | 0d | Project Administrator; Project Coordinator; Project Manager; Project Sponsor; Client Project Manager | CR | COMP | Client Phase Acceptance |
| 239 | E.RM.080 | Release Staff | milestone | 0h | 2000-02-25 | 2000-02-25 | 237 | 0d | Project Coordinator; Project Staff; Project Manager; Client Project Manager | RM | COMP | Released Staff |
| 240 | E.RM.090 | Release Physical Resources | milestone | 0h | 2000-02-25 | 2000-02-25 | 239 | 0d | Project Coordinator; Project Manager | RM | COMP | Released Physical Resources |
| 241 | E.QM.050 | Perform Quality Assessment | milestone | 0h | 2000-02-25 | 2000-02-25 | 237 | 0d | Project Manager; Quality Auditor | QM | COMP | Quality Report |
| 242 | E.CM.060 | Audit Key Deliverables | milestone | 0h | 2000-02-25 | 2000-02-25 | 237 | 0d | Project Administrator; Project Manager; Configuration Manager | CM | COMP | Audited Phase Baseline |
| 243 | E.CO.END | End Phase Completion | milestone | 0h | 2000-02-25 | 2000-02-25 | 238 | 0d |  | CO | COMP |  |
| 244 | F | **Production** |  | 0d | 2000-02-25 | 2000-02-25 |  | 0d |  |  |  |  |
| 245 | F.PL.PLAN | **Phase Planning** |  | 0d | 2000-02-25 | 2000-02-25 |  | 0d |  | PL | PLAN |  |
| 246 | F.PL.BEG | Begin Phase Planning | milestone | 0h | 2000-02-25 | 2000-02-25 | 213, 211 | 0d |  | PL | PLAN |  |
| 247 | F.PL.SUM | Review and Revise Project Plans | milestone | 0h | 2000-02-25 | 2000-02-25 | 246 | 0d | Project Administrator; Project Coordinator; Project Staff; Project Manager; Quality Manager; Configuration Manager; Project Sponsor; Consulting Business Manager; Client Project Manager | PL | PLAN |  |
| 248 | F.PL.END | End Phase Planning | milestone | 0h | 2000-02-25 | 2000-02-25 | 247 | 0d |  | PL | PLAN |  |
| 249 | F.PS.EXEC | **Post-System Support** |  | 0d | 2000-02-25 | 2000-02-25 |  | 0d |  | PS | EXEC |  |
| 250 | F.PS.BEG | Begin Production Execution | milestone | 0h | 2000-02-25 | 2000-02-25 | 248, 230 | 0d |  | PS | EXEC |  |
| 251 | F.PS.010 | Audit System | milestone | 0h | 2000-02-25 | 2000-02-25 | 250 | 0d | Project Manager; Quality Auditor | PS | EXEC | System Evaluation |
| 252 | F.PS.020 | Specify Performance Metrics | milestone | 0h | 2000-02-25 | 2000-02-25 | 250 | 0d | Business Analyst; Technical Expert | PS | EXEC | Performance Metrics |
| 253 | F.PS.030 | Measure System Performance | milestone | 0h | 2000-02-25 | 2000-02-25 | 252 | 0d | Programmer; Technical Expert | PS | EXEC | Performance Statistics |
| 254 | F.PS.040 | Agree on Performance Exceptions | milestone | 0h | 2000-02-25 | 2000-02-25 | 253FS-5% | 0d | Project Manager | PS | EXEC | Performance Exceptions |
| 255 | F.PS.050 | Analyze Problems | milestone | 0h | 2000-02-25 | 2000-02-25 | 256FS-7.5% | 0d | Business Analyst | PS | EXEC | Fault Corrections |
| 256 | F.PS.060 | Monitor and Respond to System Problems | milestone | 0h | 2000-02-25 | 2000-02-25 | 250 | 0d | Programmer | PS | EXEC | Problem Log |
| 257 | F.PS.070 | Analyze Performance Exceptions | milestone | 0h | 2000-02-25 | 2000-02-25 | 254 | 0d | Module Designer; Production Database Admin; Programmer | PS | EXEC | Performance Corrections |
| 258 | F.PS.080 | Prepare Application Upgrade Strategy and Plan | milestone | 0h | 2000-02-25 | 2000-02-25 | 250 | 0d | Project Manager | PS | EXEC | Upgrade Stategy and Plan |
| 259 | F.PS.090 | Produce Upgrade Scripts and Procedure | milestone | 0h | 2000-02-25 | 2000-02-25 | 258, 250 | 0d | Programmer | PS | EXEC | Upgrade Scripts and Procedure |
| 260 | F.PS.100 | Make Application Changes | milestone | 0h | 2000-02-25 | 2000-02-25 | 257FS-7.5%, 255FS-7.5%, 259, 258 | 0d | Programmer | PS | EXEC | Application Upgrade |
| 261 | F.PS.110 | Test Application Upgrade | milestone | 0h | 2000-02-25 | 2000-02-25 | 260 | 0d | Production Database Admin; Programmer; System Administrator; Project Manager | PS | EXEC | Upgrade Test Results |
| 262 | F.PS.120 | Upgrade Application | milestone | 0h | 2000-02-25 | 2000-02-25 | 261 | 0d | Production Database Admin; Programmer; System Administrator | PS | EXEC | Upgraded Application System |
| 263 | F.PS.130 | Determine Future Functional Enhancements | milestone | 0h | 2000-02-25 | 2000-02-25 | 251 | 0d | Business Analyst | PS | EXEC | Future Functional Enhancements |
| 264 | F.PS.140 | Plan Enhancements | milestone | 0h | 2000-02-25 | 2000-02-25 | 263 | 0d | Business Analyst; Project Manager | PS | EXEC | Enhancement Plan |
| 265 | F.PS.END | End Production Execution | milestone | 0h | 2000-02-25 | 2000-02-25 | 270, 264, 262 | 0d |  | PS | EXEC |  |

| ID | WBS | Task | Type | Duration | Start | Finish | Predecessors | Total slack | Resources | Text2 | Text3 | Text1 |
| --- | --- | --- | --- | --- | --- | --- | --- | --- | --- | --- | --- | --- |
| 266 | F.CT.CTRL | **Phase Control** |  | 0d | 2000-02-25 | 2000-02-25 |  | 0d |  | CT | CTRL |  |
| 267 | F.CT.BEG | Begin Phase Control | milestone | 0h | 2000-02-25 | 2000-02-25 | 250 | 0d |  | CT | CTRL |  |
| 268 | F.CT.SUM | Phase Control | milestone | 0h | 2000-02-25 | 2000-02-25 | 267 | 0d | Project Administrator; Project Coordinator; Project Staff; Project Manager; Quality Manager; Reviewer; Configuration Manager; Quality Auditor; Project Sponsor; Consulting Business Manager; Client Project Manager | CT | CTRL |  |
| 269 | F.CT.RES | Unallocated Reserve | milestone | 0h | 2000-02-25 | 2000-02-25 | 267 | 0d | Unassigned Resource | CT | CTRL |  |
| 270 | F.CT.END | End Phase Control | milestone | 0h | 2000-02-25 | 2000-02-25 | 269, 268 | 0d |  | CT | CTRL |  |
| 271 | F.CO.COMP | **Project Completion** |  | 0d | 2000-02-25 | 2000-02-25 |  | 0d |  | CO | COMP |  |
| 272 | F.CO.BEG | Begin Project Completion | milestone | 0h | 2000-02-25 | 2000-02-25 | 265, 243 | 0d |  | CO | COMP |  |
| 273 | F.CR.080 | Secure Client Project Acceptance | milestone | 0h | 2000-02-25 | 2000-02-25 | 278FS-7.5%, 275FS-10%, 276FS-7.5% | 0d | Project Administrator; Project Coordinator; Project Manager; Project Sponsor; Client Project Manager | CR | COMP | Client Project Acceptance |
| 274 | F.RM.080 | Release Staff | milestone | 0h | 2000-02-25 | 2000-02-25 | 272 | 0d | Project Coordinator; Project Staff; Project Manager; Client Project Manager | RM | COMP | Released Staff |
| 275 | F.RM.090 | Release Physical Resources | milestone | 0h | 2000-02-25 | 2000-02-25 | 274 | 0d | Project Coordinator; Project Manager | RM | COMP | Released Physical Resources |
| 276 | F.QM.050 | Perform Quality Assessment | milestone | 0h | 2000-02-25 | 2000-02-25 | 272 | 0d | Project Manager; Quality Auditor | QM | COMP | Quality Report |
| 277 | F.CM.060 | Audit Key Deliverables | milestone | 0h | 2000-02-25 | 2000-02-25 | 272 | 0d | Project Administrator; Project Manager; Configuration Manager | CM | COMP | Audited Phase Baseline |
| 278 | F.CM.070 | Conclude Configuration Management | milestone | 0h | 2000-02-25 | 2000-02-25 | 277 | 0d | Project Manager; Configuration Manager; Client Project Manager | CM | COMP | CM Operational Readiness |
| 279 | F.CO.END | End Project Completion | milestone | 0h | 2000-02-25 | 2000-02-25 | 273 | 0d |  | CO | COMP |  |
